# Fedora 24
#
# Copyright 2011 John Poelstra <poelstra@fedoraproject.org>
# Copyright 2011 Robyn Bergeron <rbergero@fedoraproject.org>
# Copyright 2012-2014 Jaroslav Reznik <jreznik@fedoraproject.org>
# Copyright 2015-2016 Jan Kurik <jkurik@fedoraproject.org>
#
# Permission is hereby granted, free of charge, to any person
# obtaining a copy of this software and associated documentation files
# (the "Software"), to deal in the Software without restriction,
# including without limitation the rights to use, copy, modify, merge,
# publish, distribute, sublicense, and/or sell copies of the Software,
# and to permit persons to whom the Software is furnished to do so,
# subject to the following conditions:
#
# The above copyright notice and this permission notice shall be
# included in all copies or substantial portions of the Software.
#
# THE SOFTWARE IS PROVIDED "AS IS", WITHOUT WARRANTY OF ANY KIND,
# EXPRESS OR IMPLIED, INCLUDING BUT NOT LIMITED TO THE WARRANTIES OF
# MERCHANTABILITY, FITNESS FOR A PARTICULAR PURPOSE AND
# NONINFRINGEMENT.  IN NO EVENT SHALL THE AUTHORS OR COPYRIGHT HOLDERS
# BE LIABLE FOR ANY CLAIM, DAMAGES OR OTHER LIABILITY, WHETHER IN AN
# ACTION OF CONTRACT, TORT OR OTHERWISE, ARISING FROM, OUT OF OR IN
# CONNECTION WITH THE SOFTWARE OR THE USE OR OTHER DEALINGS IN THE
# SOFTWARE.
#



macro major         [25]         # Current release version
macro previous_major[24]         # Last release version
macro next_major    [26]         # Next release version
macro content       [f]          # do not change this
macro content_title [Fedora]     # do not change this
#macro start_date    [2016-06-07] # GA date of previous release
macro start_date    [2016-05-06] # GA date of previous release
macro start_work    [2016-06-07] # set to one day after "start_date"
macro end_date      [2017-08-31]
macro id            [$Id: f-25.tjp,v 1.14 2016/08/19 06:33:25 jkurik Exp $]
macro state         [$State: Exp $]
macro prior_project [23]
macro flock_starts  [2016-08-02]
macro flock_ends    [2016-08-05]
# set to [ - no earlier than] before final schedule approval on Change Proposals
# submission deadline, otherwise set it to [ ]
macro no_earlier    [ ]

project ${content}${major} "${content_title}" "${major}" ${start_date} - ${end_date} {
  timeformat "%Y-%b-%d"

  # Based on Eastern time zone in USA
  timezone "America/New_York"

  # Add Process Link capabilities
  extend task {
    reference PTask "Process Link"
  }

  # Setup scenarios
  scenario plan "Original Plan" {
    scenario actual "Actual"
  }

  # Limit working days
  workinghours sat,sun off
}

include "reports.tji"

# =========  Cornerstones of Fedora Schedules =============
# This section also serves as a "style guide" for the source file too

/*
1) EVERY entry should be in the following line order and indented consistently with the rest of the file.  This makes the source file consistent and eaiser to read.
   a) task name and description
   b) dependency (if applicable)
   c) length (not "duration") (if applicable)
   d) flags (if applicable)

2) Time driven unless specified differently during planning

3) Freezes and releases always happen on Tuesdays. Tuesday has been determined to be the best day for Press announcements and kept for deadlines to maintain historical consistency. Also mirroring happens during weekend - less stress on mirrors. Additionally FESCo agreed on Wednesday and Thursday release dates to avoid potential conflicts with important events (holidays etc.) but it should not be used unless galaxies are going to collide ;-). See https://fedorahosted.org/fesco/ticket/974

4) Syncing releases to mirrors ideally happens on Thursdays... end of day on Friday is worst case

5) Most tasks are scheduled with 'length' instead of 'duration' to get a sense of "work days" required--using 'length' one week = 5 days
--an eternal debate could be held to discuss whether or not schedule calculations
should include weekends because community members work at all times and not within strict work days.

6) There is little to no benefit found in including a holiday.tji file for Fedora.  In some cases it made the scheduling more complicated.

7) Use "length" everywhere and "duration" only when something must take into account a weekend day

8) If a task takes one day or less--schedule with no length--this way it showes up as a milestone and gets included in iCalendar (ics) file

9) Because of bugs in the way TaskJuggler ics files get rendered in some calendars (e.g. Zimbra) we only include zero length (milestone) tasks in the ics file.  As a result there are several duplicate tasks with no length that have been added so they appear in the ics file.

10) There are five primary projects the Fedora Translation team works on:
a) Software localization
b) Guides localization
c) Release Notes localization
d) Website localization
e) Release banner localization

11) Use core schedule milestones (flags = key) as anchor points (depends/precedes) for tasks in this schedule file instead of more transient tasks like meetings, compose dates, etc. that may change (or slip) from release to release.  This makes building new release schedules easier and require less maintenance and updating. Except tasks where slip moves release.
Exception - currently release is tied to Go/No-Go meeting (to be changed)

12) In ALL but limited cases task beginning and ending should be automatically calculated based on logic in this file.  When using hard coded dates, explicitly call them out with a comment to hightlight their existence.  Hard coded dates are particularly troublesome when slipping a schedule or branching the file to create a new release schedule because they must be adjusted and recalculated manually

13) TaskJuggler does not provide an easy way (that I am aware of) to schedule tasks to happen *before* other tasks.  I've created a hack/methodology I call "shadow" tasks.  These are unreported tasks that go backwards a certain period of time and serve as an anchor or starting point for the actual task to be reported.

14) Slipping a particular release milestone, but then holding the rest of the schedule to its original dates, requires a lot of tedious tweaking and is a real hassle--it usually results in a slip anyway.  Fedora has a poor history of being able absorb slips and it usually results in a slip later in the release cycle.  This is because the time period between Alpha Deadline and the final release has already been compressed as much as possible.

15) The "milestone" declaration is NOT used in this source file.  It is redundant and unnecessary.  Do not inlude it.  All tasks without 'length' or 'duration' are automatically considered "milestone" tasks.

16) Keep the indentation and alignment consistent throughout the file--it makes it easier to read and grok
  a) select all the text in the source file
  b) Tools/Clean Indention
c) Tools/Align
*/

# ============ What should be included in TaskJuggler? ==============
/*
e.g.that *should* be tracked in this schedule vs. subgroup ticketing or task systems
1) Inter-team dependencies.  For example Docs team release-notes.rpm or Artwork team packages needed by Release Eng for complete distro creation.

2) Significant tasks that are important for other groups to be aware of

3) Tasks critical to releasing a new version of Fedora.  For example, composing test releases, testing releases, syncing the release to the mirrors, etc.

4) Tasks that must be completed for a quality release--"nice to have" items should be tracked elsewhere and clutter the schedule

5) In general we have found it to be ineffective to create overly-detailed schedules for the subteams because they are hard to maintain and the ROI appears to be low
*/

# ============ How to Build a schedule for a new release ==============
/*
It has worked really well to roll the current release TaskJuggler source file forward (copy/paste) to the next version
and then modify it from there.  I usually branch a new TaskJuggler source file for the next release approximately one
month before GA.

Once branched I make sure that any important structural changes to the current schedule get reflected in the new one.

Changing the release methodology--length between different milestones and deadlines--every new release has been a a lot of work to make sure all the individual team schedules continue to work properly.  This is because many of the team schedules are anchored to key milestones and deadlines.  From Fedora 13 to 14 the methodology remained the same which made creating the Fedora 14 schedule much easier.  New schedule methodology should be tried out for at least two releases in a row before changing unless a serious deficiency is identified..

Here is my step-by-step process:

1) Copy f-<release-version>.tjp to f-<new-release-version>.tjp (maintain same file and folder naming)

2) Remove all task length designations of "planned" and "actual" (used to reflect delta from original plan) so that there is only one length/duration declaration--"planned" is the default if not specified and this gets you back to the baseline schedule before it slipped.

3) Adjust planning duration and recalculate schedule until desired GA date is reached
--this is a somewhat strange way to design a schedule, but the full methodology is described here
http://fedoraproject.org/wiki/LifeCycle

4) Search source for all instances of "# ADJUST FOR NEW RELEASE" and "# KEY ADJUSTMENT POINT"--these are tasks that may need their length manually adjusted so they land on the right day or the description adjusted.  They should also be considered if the schedule slips.

5) Fix all of the macros at the start of the file to reflect the correct release information

6) Update the html reports headers to reflect the two correct past releases: "macro all_navbar"


Note:
during Fedora 21 release, we renamed a few milestones. This file does not contain all changes as it would be retrospective change.

# ===============   TODO: Unfinished Items ================ #
/*

1)
2)

*/


task ${content}${major} "${content_title} ${major}" {

  start ${start_work}

  task first_day "First Day of Development" {
    flags hidden
  }

  task prd_review "PRD review" {
    PTask "https://fedorahosted.org/council/ticket/27"
    flags council

    task prd_preparation "Proposals of PRD changes" {
        precedes !prd_workshop_flock {gaplength 1d}
        length 9d
        flags council
    }

    task prd_council_ticket "Ticket to be created to track changes in PRDs" {
      precedes !prd_workshop_flock {gaplength 9.5d}
      PTask "https://fedorahosted.org/council/ticket/63"
      flags council, pm
      length 1h
    }

    task reminder_to_wgs "REMINDER: WGs to be notified to send proposed updates to the Fedora Council" {
      precedes !prd_workshop_flock {gaplength 9.5d}
      flags council, pm
      length 1h
    }

    task prd_workshop_flock "PRD workshop on FLOCK" {
        start ${flock_starts}
        end ${flock_ends}
        flags council
    }

    task prd_approval "PRD approval" {
        depends !prd_workshop_flock {gaplength 1d}
        length 9d
        flags council
    }

  }

  # This task is required for the Product Pages
  # taskid and description should not be changed
  task PlanningPhase "Planning Phase" {

    # add for ical
    task start_features_cal "Start Change Proposals Submission" {
      flags key, pm, roadmap
    }

    # Requirements gathering task is added here to satisfy RedHad Schedule Mandatory items
    # Do not change the name (description) of this task
    task requirements_gathering "Requirements Gathering" {
      depends !start_features_cal
      flags hidden, roadmap
    }

    task rawhide_spins "Start Nightly Spins Compose Based on Rawhide" {
      depends !!first_day {gaplength 5d}
      flags spins
    }

    # Previously approval from FESCo was needed but we do not do it anymore
    # The process behind this task is at: https://fedoraproject.org/wiki/BugZappers/HouseKeeping
    task fedora22_eol "Fedora 22 EOL auto closure" {
      depends !!LaunchPhase.final {gaplength 20d}
      flags pm, key
    }

    task clean_market_wiki "Cleanup Marketing wiki from previous releases" {
      depends !start_features_cal {gaplength 25d}
      length 5d
      flags marketing
    }

    task cycle_market_wiki "Cycle Marketing wiki pages for current release" {
      depends !start_features_cal {gaplength 25d}
      length 5d
      flags marketing
    }

    task bug_trackers "Create Tracker Bugs" {
      flags pm
      note "See details at https://fedoraproject.org/wiki/BugZappers/HouseKeeping/FirstDayDevel"
    }

    # FIXME: make sure this lines up right in light of proposed design schedule 2010-11-08
    task design_concept "Conceptual Design Phase" {
      length 30d
      flags design
    }

    # FIXME: make sure this lines up right in light of proposed design schedule 2010-11-08
    # FIXME: make sure this lines up right and reconsider if calculation could be automatic
    # ADJUST FOR NEW RELEASE
    # a solid start for the wallpaper is the goal for alpha
    # adjust length so packaging end date lands on Alpha Deadline
    task wallpaper_design "Wallpaper Design for Alpha" {
      depends !design_concept
      length 57d
      flags design
    }

  } # E N D  of  PlanningPhase


  task supplement_wallpaper "Supplemental Wallpaper Process" {
    flags design

    # ADJUST FOR NEW RELEASE
    # adjust length of this task so that 'package_supplemental_wallpaper' ends on Beta Deadline
    task supplement_wallpaper_submit "Supplemental Wallpaper Submission Period" {
      length 107d
    }

    task decide_supplement_wallpaper "Select Official Supplemental Wallpaper" {
      depends !supplement_wallpaper_submit
      length 5d
    }

    task supplement_license_review "Verify Supplemental Wallpaper Licenses" {
      depends !supplement_wallpaper_submit
      length 5d
    }

    task package_supplemental_wallpaper "Package Supplemental Wallpaper" {
      depends !supplement_license_review
      length 2d
    }

  } # end supplemental wallpaper


  # This task is required for the Product Pages
  # taskid and description should not be changed
  task DevelopmentPhase "Development Phase" {
    start ${start_work}

    task devel_start "Start Development" {
      flags devel
    }

    # ADJUST FOR NEW RELEASE--IMPORTANT
    # The length of this task DRIVES THE ENTIRE SCHEDULE
    # and determines when the testing phases starts.  The testing
    # phase of the schedule is static (and completely automatically
    # generated by TaskJuggler) from release to release, but the
    # number of days of development varies depending when the previous
    # release ended (GA).  As a result the length of this task also
    # influences where the GA date lands.
    # Each "5d" (5 days) is equivalent to one week.
    task develop "Packaging and Development (precedes Alpha)" {
      length 46d
      flags devel, proto
    }

    # This task is required for the Product Pages
    # taskid and description should not be changed or displayed
    task export_freeze "Requirements Freeze" {
      depends !develop
      flags hidden
    }

    task fedora_change_accepted "Request 'Fedora ${major} Change accepted' badge" {
      depends !devel_start
      PTask "https://fedorahosted.org/fedora-badges/ticket/417" { }
      flags pm
    }

  }  # E N D  of DevelopmentPhase

  task TestingPhase "Testing Phase" {

    task alpha "Alpha Release" {

      # FIXME: this task is just contemporary to make sure the Alpha phase is shown before Beta phase in reports
      task alpha_before_beta "SHADOW: Alpha release before Beta release" {
        precedes !!beta
        length 1min
        flags hidden
      }

      task remind_alpha_blocker "Reminder: Alpha Blocker Meeting (${content}${major}alpha)" {
        precedes !alpha_blocker {gaplength 3d}
        length 1h
        flags pm
      }

      task alpha_blocker "Alpha Blocker Meeting (${content}${major}alpha)" {
        depends !remind_alpha_go_not
        flags releng, quality, devel, pm, blocker
      }

      task self_contained_changes_submission_deadline_1_week "REMINDER: Change Checkpoint: Proposal submission deadline (Self contained Changes) in one week" {
        depends !shadow_feature_submission_deadline {gaplength 6d}
        flags pm
      }

      task self_contained_changes_submission_deadline "Change Checkpoint: Proposal submission deadline (Self contained Changes)" {
        depends !shadow_feature_submission_deadline {gaplength 11d}
        flags pm, key, devel
      }

      # Change Proposals Freeze is one week before Alpha Change Deadline
      # Automatically calculated based on Alpha Change Deadline
      task shadow_feature_freeze "SHADOW: Anchor Change Proposals Freeze" {
        precedes !alpha_deadline {gaplength 11d}
        flags hidden
      }

      # Requirements finalized task is added here to satisfy RedHad Schedule Mandatory items
      # Do not change the name (description) of this task
      task requirements_finalized "Requirements Finalized" {
        depends !shadow_feature_freeze
        flags hidden, roadmap
      }

      task feature_freeze "Change Checkpoint: Completion deadline (testable)${no_earlier}" {
        depends !shadow_feature_freeze
        flags releng, quality, pm, proto, devel, key, marketing, roadmap, fpl
        PTask "https://fedoraproject.org/wiki/Changes/Policy#Change_freeze" { }
      }

      task create_test_days "Create test days" {
        depends !shadow_feature_freeze
        flags quality
        PTask "https://fedoraproject.org/wiki/QA/Test_Days" { }
      }

      task feature_freeze_deadline_announce "Announce Change Checkpoint: Completion deadline (testable) Reached" {
        depends !feature_freeze
        flags pm
      }

      task award_change_badges "Award people having accepted Changes into the release" {
        depends !feature_freeze
        flags pm
        PTask "https://fedorahosted.org/fedora-badges/ticket/417"
      }

      task alpha_deadline_remind "Remind Alpha Freeze in 1 week" {
        precedes !alpha_deadline {gaplength 5d}
        length 1h
        flags pm
      }

      task next_schedule_prep "Preparation of a new schedule for Fedora ${next_major}" {
        depends !shadow_feature_freeze
        length 6d
        flags pm
      }

      task next_schedule_fesco "Approval of the schedule for Fedora ${next_major} by FESCo" {
        depends !next_schedule_prep
        flags pm
      }

      task talking_points "Create Talking Points" {
        depends !feature_freeze {gaplength 6d}
        length 5d
        flags marketing
      }


      task feature_profiles "Proposed Changes Profiles" {
        depends !talking_points
        length 20d
        flags marketing
      }

     task compose_tooling_completed "Compose tooling completed deadline" {
        depends !self_contained_changes_submission_deadline_1_week
        flags releng, pm, infrastructure
     }

      # Branch on the same Tuesday as Change Proposals Freeze
      task branch_rawhide "Branch Fedora ${major} from Rawhide" {
        depends !shadow_feature_freeze
        flags releng, devel, pm, proto, key, roadmap, fpl
      }

      task bugzilla_descrption "Reflect supported versions in Bugzilla product description" {
        depends !shadow_feature_freeze
        flags pm
      }

      task rawhide_rebase "Rebase Rawhide bugs to Fedora ${major}" {
        depends !shadow_feature_freeze
        flags pm
      }

      # Create anchor for three weeks before for Change Proposals Submission
      task shadow_feature_submit_remind_3_weeks "SHADOW: Three Weeks Before Change Proposals Submission" {
        precedes !feature_submission_deadline {gaplength 15d}
        flags hidden
      }

      # Three weeks before Change Proposals Submission Deadline
      task feature_check_remind "Request Changes Status Updates + Remind Submit Deadline" {
        depends !shadow_feature_submit_remind_3_weeks
        flags devel, pm
      }

      task feature_submit_remind_2_weeks "Change Proposals Submission Deadline Two Weeks away" {
        depends !shadow_feature_submit_remind_3_weeks {gaplength 6d}
        flags devel, pm
      }

      #two weeks before spins submission deadilen get wiki pages in order
      task spins_wiki_update "Update All Spins Wiki Pages From Previous Releases" {
        depends !shadow_feature_submit_remind_3_weeks
        flags spins
      }

      task feature_submit_remind_1_week "Change Proposals Submission Deadline One Week away" {
        depends !shadow_feature_submit_remind_3_weeks {gaplength 11d}
        flags devel, pm
      }

      task shadow_feature_mass_rebuild_deadline "SHADOW: Four weeks to mass rebuild" {
        precedes !feature_freeze {gaplength 30d}
        flags hidden
      }

      task feature_mass_rebuild_submit_remind_1_week "Remind Change Checkpoint: Proposals requiring mass rebuild submission deadline in one week" {
        precedes !shadow_feature_mass_rebuild_deadline {gaplength 5d}
        flags devel, pm
      }

      task feature_mass_rebuild_deadline "Change Checkpoint: Proposals requiring mass rebuild submission deadline" {
        depends !shadow_feature_mass_rebuild_deadline
        flags releng, pm, key, quality
      }

      # Create anchor for two weeks before Change Proposals Freeze
      task shadow_feature_submission_deadline "SHADOW: Two weeks before Change Proposals Freeze" {
        precedes !feature_freeze {gaplength 15d}
        flags hidden
      }

      task feature_submission_deadline "Change Checkpoint: Proposal submission deadline (System Wide Changes)" {
        depends !shadow_feature_submission_deadline
        flags releng, quality, pm, proto, devel, key, roadmap, fpl
      }

      task mass_rebuild "Mass rebuild (if needed)" {
        depends !shadow_feature_submission_deadline {gaplength 4d}
        flags releng, pm, key
        length 15d
        PTask "https://docs.pagure.org/releng/sop_mass_rebuild.html" { }
      }

      task call_test_days "Call for test days" {
        depends !shadow_feature_submission_deadline
        flags quality, pm
        PTask "https://fedoraproject.org/wiki/QA/Test_Days" { }
      }

      task feature_submission_deadline_announce "Announce   Change Checkpoint: Proposal submission Closed" {
        depends !shadow_feature_submission_deadline
        flags pm
      }

      task spins_submission_deadline "Custom Spins Submission Deadline" {
        depends !shadow_feature_submission_deadline
        flags pm, proto, key, spins, fpl
      }

      task warn_rawhide_rebase "Rawhide Rebase Warning to Package Maintainers" {
        depends !shadow_feature_submission_deadline
        flags pm
      }

      task feature_incomplete_nag "Remind not in MODIFIED Changes Owners" {
        depends !feature_freeze {gaplength 1d}
        flags pm
      }

      task feature_incomplete_fesco "Deliver Incomplete Changes to FESCo" {
        depends !feature_freeze {gaplength 2d}
        flags pm
      }

      # KEY ADJUSTMENT POINT
      # Date of Alpha Deadline depends on length of development
      task alpha_deadline "Alpha Freeze${no_earlier} (00:00 UTC)" {
        depends !!!DevelopmentPhase.develop
        flags releng, quality, pm, devel, key, roadmap, proto, blocker, spins
        PTask "https://fedoraproject.org/wiki/Milestone_freezes" { }
      }

      # Development freeze task is added here to satisfy RedHad Schedule Mandatory items
      # # Do not change the name (description) of this task
      task development_freeze "Development Freeze" {
        depends !alpha_deadline
        flags hidden, roadmap
      }

      task alpha_bodhi "Bodhi activation point" {
        depends !alpha_deadline
        flags pm, devel, key
      }

      task alpha_deadline_announce "Announce Alpha Freeze Reached" {
        depends !alpha_deadline
        flags pm
      }

      # KEY ADJUSTMENT POINT--manually adjust if length of time before Alpha ships changes
      task alpha_infrastructure_freeze "Alpha Infrastructure Change Freeze" {
        depends !alpha_deadline
        length 10d
        flags infrastructure
      }

      task alpha_spins_ks "Build spin-kickstarts package from master" {
        depends !alpha_deadline
        flags spins
      }

      # Happens the same day as Change Proposals Freeze
      task orphan "Retire Orphaned and Long-Time FTBFS Rawhide Packages" {
        depends !feature_freeze
        flags releng, devel
      }

      task finalize_alpha_wallpaper "Finalize Alpha Wallpaper" {
        depends !!!PlanningPhase.wallpaper_design
        flags design, pm
        length 3d
      }

      task alpha_wallpaper_deadline "Alpha Wallpaper Deadline" {
        depends !finalize_alpha_wallpaper
        flags design
      }

      task blog_alpha_wallpaper "Blog About Alpha Wallpaper" {
        depends !finalize_alpha_wallpaper
        flags design
      }

      # must land a few days before Alpha compose by Releng
      task package_alpha_wallpaper "Package Alpha Wallpaper" {
        depends !finalize_alpha_wallpaper
        length 2d
        flags design
      }

      task alpha_wallpaper_feedback "Solicit Feedback on Alpha Wallpaper" {
        depends !package_alpha_wallpaper
        length 10d
        flags design
      }

      # depends on nearly complete version of the wallpaper, otherwise
      # you have to create the splashes twice
      # work on until Beta freeze
      task start_splash_screens "Create Splash Screens" {
        depends !alpha_drop
        length 9d
        flags design
      }

      # for ics file
      task start_splash_screens_cal "Start Splash Screens" {
        depends !alpha_drop
        flags design
      }

      # work on until Beta freeze
      task finalize_splash_screens "Finalize Splash Screens" {
        depends !start_splash_screens
        length 4d
        flags design
      }

      # work on until Beta freeze
      task beta_wallpaper "Prepare wallpaper for Beta" {
        depends !alpha_drop
        length 13d
        flags design
      }

      # send reminder on Monday before Wednesday meeting
      task remind_alpha_go_not "Reminder: ${content_title} ${major} Alpha Go/No-Go Meeting" {
        depends !alpha_deadline {gaplength 4d}
        flags pm
      }

      # KEY ADJUSTMENT POINT - release depends on Go/No-Go meeting
      task alpha_go_not "${content_title} ${major} Alpha Go/No-Go Meeting" {
        depends !alpha_deadline {gaplength 12d}
        flags releng, quality, devel, pm, proto, blocker
      }

      task common_bugs_page "'Common bugs' page to be created" {
        depends !alpha_go_not {gaplength 1d}
        flags quality
        PTask "https://fedoraproject.org/wiki/Common_bugs" { }
      }

      task trans_software_rebuild1 "Remind f-dev-announce to Rebuild All Translated Packages" {
        depends !feature_freeze {gaplength 5d }
        flags translation
      }

      task reminder_software_string_freeze "REMINDER: Software String Freeze in one week" {
        depends !feature_freeze {gaplength 6d }
        flags pm
      }

      task software_string_freeze "Software String Freeze Reached" {
        depends !feature_freeze {gaplength 11d }
        flags devel, translation, pm, proto, releng, key, roadmap
        PTask "https://fedoraproject.org/wiki/ReleaseEngineering/StringFreezePolicy" { }
      }


      # Send reminder on Monday before Thursday meeting
      task alpha_meeting_reminder "Reminder: Alpha Release Readiness Meeting" {
        depends !alpha_deadline {gaplength 4d}
        flags pm
      }

      task alpha_meeting "${content_title} ${major} Alpha Release Readiness Meeting" {
        depends !alpha_deadline {gaplength 7d}
        flags releng, pm, quality, docs, design, translation, marketing, web
      }

      # land on a Tuesday
      task shadow_before_alpha_deadline "SHADOW: before Alpha Change Deadline" {
        precedes !alpha_deadline {gaplength 11d}
        flags hidden
      }

      task create_alpha_tc "Create First Alpha Test Compose (TC1)" {
        depends !shadow_before_alpha_deadline
        flags releng, proto
      }

      # test Wed to Wed
      task test_alpha_tc "Test Alpha 'Test Compose'" {
        depends !create_alpha_tc {gaplength 1d}
        length 17d
        flags quality, proto
      }

      # for ical file
      task start_stage_alpha "Stage Alpha on matster minor" {
        depends !alpha_go_not
        flags releng
      }

      task notify_mirrors_alpha "Notify Mirrors of ${content_title} ${major} Alpha" {
        depends !start_stage_alpha {gaplength 1d}
        flags releng
      }

      # bind to Go/No-Go meeting
      task stage_alpha "Propagation of Alpha to mirrors" {
        depends !alpha_go_not
        length 3d
        flags releng, proto
      }

      task wg_bullet_points_alpha "Email WGs to solicit bullet points for Alpha release announcement" {
        precedes !alpha_announce {gaplength 5d}
        flags marketing
        length 1min
      }

      task alpha_announce "Create Alpha Announcement (Docs & Marketing)" {
        depends !alpha_meeting
        length 2d
        flags docs, marketing
      }

      task alpha_drop "Alpha Release Public Availability${no_earlier}" {
        depends !stage_alpha
        flags releng, docs, quality, design, pm, proto, devel, key, marketing, roadmap, spins, blocker, infrastructure, fpl
      }

      task start_swag "FAmSCo and Regional teams call for Preparation of Media/SWAG" {
        depends !alpha_drop {gaplength 7d}
        flags ambassadors
      }

      task swag_poc "Regional Team Meetings and Select POC for Swag/Media production" {
        depends !alpha_drop {gaplength 8d}
        length 5d
        flags ambassadors
      }

      task reminder_software_translation_deadline "REMINDER: Software Translation Deadline in 1 week" {
        depends !alpha_drop {gaplength 5d}
        flags translation, pm
        PTask "https://fedoraproject.org/wiki/L10N_Freezes#Translation_Deadline"
      }

      task software_translation_deadline "Software Translation Deadline" {
        depends !alpha_drop {gaplength 10d}
        flags translation, pm, key
        PTask "https://fedoraproject.org/wiki/L10N_Freezes#Translation_Deadline"
      }

      # KEY ADJUSTMENT POINT
      task alpha_release_notes "Alpha Release Notes" {

        # create for ical
        task start_alpha_beats "Start Alpha Beat and Changes Page Review" {
          depends !!feature_freeze {gaplength 6d}
          flags docs
        }

        task validate_beat_writers "Validate Former Beat Writers" {
          depends !!feature_freeze
          length 5d
          flags docs
        }

        task recruite_beat_writers "Recruit New Beat Writers" {
          depends !validate_beat_writers
          length 5d
          flags docs
        }

        task comb_alpha_beats "Comb Beats and Changes Pages for Alpha" {
          depends !start_alpha_beats
          length 2d
          flags docs, quality
        }

        task notify_devel_relnotes "Notify Development About Alpha Release Notes" {
          depends !!alpha_deadline
          flags docs
        }

        # KEY ADJUSTMENT POINT
        # Beta release notes depend on this task
        # If alpha candidate is not ready on time add extra time for the release notes here
        task prep_alpha_notes "Prepare Alpha Release Notes (1 page)" {
          depends !comb_alpha_beats
          length 6d
          flags docs, quality
        }

        task post_notes "Post Alpha Release Notes One-Page" {
          depends !prep_alpha_notes {gaplength 1d}
          flags docs
        }

      } #end alpha_release_notes


      #  two days to create web banner
      #  one day for websites team to add to www.fedoraproject.org
      #  should be live one day before the release
      task alpha_banner "Alpha Release Banner" {
        precedes !alpha_drop {gaplength 3d}

        task alpha_create_banner "Create Alpha Website Banner" {
          length 2d
          flags design
        }

        task alpha_publish_banner "Add Alpha Banner to Website" {
          length 1d
          flags web
        }
      }

      # This task is required for the Product Pages
      # taskid and description should not be changed or displayed
      task public_alpha "Public Alpha" {
        depends !stage_alpha
        flags hidden
      }

      # KEY ADJUSTMENT POINT
      # Three weeks for Alpha Testing
      # IF "Beta Deadline" is missed the length of this task is extended--
      # in that case corresponding change needs to be made to "software_translation" task
      task test_alpha "Alpha Testing" {
        depends !stage_alpha
        length 15d
        flags quality, proto
      }

      task review_bookmarks "Review Firefox Bookmarks For Update" {
        depends !stage_alpha
        length 5d
        flags marketing
      }

      task update_bookmarks "Update and Package Firefox Bookmarks" {
        depends !review_bookmarks
        length 2d
        flags marketing
      }

      task tag_bookmarks "Tag Updated Bookmarks Package for ${content_title} ${major}" {
        depends !update_bookmarks
        flags marketing
      }

      # Explicit task to mark end of alpha
      # Also permits subsequent tasks to cleanly depend on it using "precedes" (because it is zero length)
      task alpha_end "End of Alpha Testing" {
        depends !test_alpha
        flags quality
      }

    }

    task beta "Beta Release" {

      # KEY ADJUSTMENT POINT--if the Alpha slips, make sure the blocker meeting
      # tasks continue to line up correctly
      # Once the Alpha is staged, start holding Blocker meetings for the Beta
      task remind_beta_blocker "Reminder: Beta Blocker Meeting (${content}${major}beta)" {
        precedes !beta_blocker {gaplength 3d}
        length 1h
        flags pm
      }

      task beta_blocker "Beta Blocker Meeting (${content}${major}beta)" {
        depends !remind_beta_go_not
        flags releng, quality, devel, pm, blocker
      }

      # Create anchor one week before for Beta Deadline
      task shadow_beta_deadline "SHADOW: one week before Beta Deadeline" {
        precedes !beta_deadline {gaplength 6d}
        flags hidden
      }

      task remind_beta_deadline "Remind Beta Deadline in 1 week" {
        depends !shadow_beta_deadline
        flags pm
      }

      task remind_final_features "Remind Change Checkpoint: 100% Code Complete Deadline in 1 week" {
        depends !shadow_beta_deadline
        flags pm
      }

      task beta_spins_ks "Build spin-kickstarts package from master" {
        depends !shadow_beta_deadline
        flags spins
      }

      task coordinate_swag_design "FAmSCo Coordinate Media/Swag/Poster artwork with Design team" {
        depends !shadow_beta_deadline {gaplength 5d}
        length 10d
        flags ambassadors
      }

      # Two weeks before the public Beta Release
      task beta_deadline "Beta Freeze${no_earlier} (00:00 UTC)" {
        depends !!alpha.test_alpha { gaplength 5d }
        flags releng, docs, quality, pm, proto, devel, key, marketing, spins, roadmap
        PTask "https://fedoraproject.org/wiki/Milestone_freezes" { }
      }

      task deliverables_review "Open ticket to FESCo requesting review of deliverables" {
        depends !beta_deadline
        flags pm
        PTask "https://fedorahosted.org/fesco/ticket/1444"
      }

      task feature_complete "Change Checkpoint: 100% Code Complete Deadline${no_earlier}" {
        depends !!alpha.test_alpha { gaplength 5d }
        flags releng, docs, quality, pm, proto, devel, key, marketing, roadmap, fpl
        PTask "https://fedoraproject.org/wiki/Changes/Policy#Beta_deadline.2Faccepted_changes_100.25_complete" { }
      }

      # KEY ADJUSTMENT POINT--manually adjust if length of time before Beta ships changes
      task beta_infrastructure_freeze "Beta Infrastructure Change Freeze" {
        depends !!alpha.test_alpha
        length 15d
        flags infrastructure, releng
      }

      task announce_beta_deadline "Announce Beta Freeze & Changes Complete" {
        depends !!alpha.test_alpha { gaplength 5d }
        flags pm
      }

      task final_feature_fesco "Deliver features < 100% to FESCo" {
        depends !beta_deadline {gaplength 1d}
        flags pm
      }

      # The Release Slogan is created by the Marketing team based on
      # the initial artwork theme. The Design Team needs to know
      # the slogan to create the release banners

      # prepare 6 weeks before GA (2 weeks of work)
      # go live 1 month before GA
      # KEY ADJUSTMENT POINT
      task create_countdown "Create Count Down Graphic" {
        depends !beta_deadline
        length 10d
        flags design
      }

      task publish_countdown "Publish Count Down Graphic" {
        depends !create_countdown
        length 1d
        flags web
      }

      task beta_release_notes "Beta Release Notes" {

        task unclaimed_beats "Write Unclaimed Wiki Beats" {
          depends !!!alpha.alpha_drop
          length 11d
          flags docs
        }

        task port_wiki_publican "Port Wiki to Publican" {
          depends !unclaimed_beats {gaplength 1d}
          length 3d
          flags docs
        }

        task remind_trans_beta_notes "Remind Translation: Beta Rel Notes POT Coming" {
          depends !unclaimed_beats
          flags docs
        }

        task start_release_notes_pot1 "Start nightly POT files all fed-rel-notes.rpm content" {
          depends !port_wiki_publican {gaplength 1d}
          flags docs
        }

        task release_notes_pot1 "Generate nightly POT files all fed-rel-notes.rpm content" {
          depends !port_wiki_publican {gaplength 1d}
          length 13d
          flags docs
        }

        task remind_devel_beta_notes"Remind announce-list & f-devel-announce: Wiki Freeze" {
          depends !unclaimed_beats {gaplength 1d}
          flags docs
        }

        task beta_wiki_freeze "Wiki Freeze: Beta Release Notes" {
          depends !remind_devel_beta_notes {gaplength 2d}
          flags docs
        }

        task trans_release_notes "Translate Beta Release Notes" {
          depends !port_wiki_publican {gaplength 1d}
          length 3d
          flags translation
        }

        # KEY ADJUSTMENT POINT
        task build_trans_review "Ongoing build translation review htmls" {
          depends !beta_wiki_freeze
          length 5d
          flags docs
        }

        # KEY ADJUSTMENT POINT
        task trans_review_beta "Review and correct Beta Release Notes (daily buids html)" {
          depends !beta_wiki_freeze
          length 5d
          flags translation
        }

        task trans_release_notes_deadline "Translation Deadline: Beta Release Notes (PO Files complete)" {
          depends !trans_review_beta
          flags translation, docs
        }

        task build_beta_relnotes "Build f-r-n.rpm and Push to updates-candidate" {
          depends !trans_release_notes_deadline
          length 2d
          flags docs, translation
        }

        task final_release_notes_reminder "Reminder: Send Project Wide-Final Release Notes Deadlines" {
          depends !!beta_deadline {gaplength 7d}
          flags docs
        }

        # one day before release which is 2D after meeting
        task web_notes "Build and Post Beta release-notes to docs.fedoraproject.org" {
          depends !!beta_meeting {gaplength 2d}
          flags docs
        }

        # one day before release which is 2D after meeting
        # FIXME: jjmcd needs to do this the day AFTER beta is released - beta repo is needed to build this
        task tech_web_notes "Build and Post Fedora Technical Notes to docs.fedoraproject.org" {
          depends !!beta_meeting {gaplength 2d}
          flags docs
        }

      } # end beta_release_notes


      task splash_deadline "Deadline: Beta Splash Screens" {
        depends !!alpha.finalize_splash_screens { gaplength 5d }
        flags design
      }

      task package_final_splash "Package: Beta Splash Screens" {
        depends !!alpha.finalize_splash_screens { gaplength 5d }
        length 2d
        flags design
      }

      task package_beta_wallpaper "Package: Beta Wallpaper"{
        depends !!alpha.beta_wallpaper { gaplength 5d }
        length 2d
        flags design
      }

      task package_supplemental_wallpaper "Package: Supplemental Wallpaper"{
        depends !!alpha.beta_wallpaper { gaplength 5d }
        flags design
      }

      # KEY ADJUSTMENT POINT if Beta Deadline changes
      task beta_meeting_reminder "Reminder: Beta Release Readiness Meeting" {
        depends !beta_deadline {gaplength 4d}
        flags pm
      }

      task beta_meeting "${content_title} ${major} Beta Release Readiness Meeting" {
        depends !beta_meeting_reminder {gaplength 3d}
        flags releng, pm, quality, docs, design, translation, marketing, web
      }


      task wg_bullet_points_beta "Email WGs to solicit bullet points for Beta release announcement" {
        precedes !beta_announce {gaplength 5d}
        flags marketing
        length 1min
      }

      task beta_announce "Create Beta Announcement (Docs & Marketing)" {
        depends !beta_meeting
        length 2d
        flags docs, marketing
      }

      task shadow_before_beta_deadline "SHADOW: before Beta deadline" {
        precedes !beta_deadline {gaplength 11d}
        flags hidden
      }

     task beta_installer_build1 "Submit Installer Build for Beta TC Compose" {
        depends !shadow_before_beta_deadline
        flags devel
      }

      task create_beta_tc "Create First Beta Test Compose (TC1)" {
        depends !shadow_before_beta_deadline {gaplength 1d}
        flags releng, proto
      }

      task test_beta_tc "Test Beta 'Test Compose'" {
        depends !create_beta_tc
        length 17d
        flags quality, proto
      }

      task remind_beta_go_not "Reminder: ${content_title} ${major} Beta Go/No-Go Meeting" {
        depends !beta_deadline {gaplength 4d}
        flags pm
      }

      task beta_go_not "${content_title} ${major} Beta Go/No-Go Meeting" {
        depends !beta_deadline {gaplength 7d}
        flags releng, quality, devel, pm, proto, blocker
      }

      task common_bugs_page_beta_update "'Common bugs' page to be updated" {
        depends !beta_go_not {gaplength 1d}
        flags quality
        PTask "https://fedoraproject.org/wiki/Common_bugs" { }
      }

      # KEY ADJUSTMENT POINT if Beta release date slips--add more time to this task
#      task create_beta_compose "Compose Beta Candidate" {
#        depends !beta_deadline {gaplength 2d}
#        flags releng, proto
#      }

      task call_for_events "FAmSCo and Regional Teams Call for Release Events" {
        depends !beta_deadline {gaplength 12d}
        flags ambassadors
      }

      task logistics_budget "Regional Teams Plan Regional Logistics for Release Events" {
        depends !call_for_events
        length 10d
        flags ambassadors
      }

      task start_stage_beta "Stage Beta on matster minor" {
        depends !beta_go_not
        flags releng
      }

      task notify_mirrors_beta "Notify Mirrors of ${content_title} ${major} Beta" {
        depends !start_stage_beta {gaplength 1d}
        flags releng
      }

      task stage_beta "Propagation of Beta to mirrors" {
        depends !beta_go_not
        length 3d
        flags releng, proto
      }


      # two days to create web banner
      # one day for websites team to add to www.fedoraproject.org
      # should be live one day before the release
      task beta_banner "Beta Release Banner" {
        precedes !beta_drop {gaplength 3d}

        task beta_create_banner "Create Beta Website Banner" {
          length 2d
          flags design
        }

        task beta_publish_banner "Add Beta Banner to Website" {
          length 1d
          flags web
        }
      }

    task shadow_before_beta_drop "SHADOW: One Day before Public Beta release" {
      precedes !beta_drop {gaplength 2d}
      flags hidden
    }

      # Five weeks prior to GA
      task beta_drop "Beta Release Public Availability${no_earlier}" {
        depends !stage_beta
        flags docs, releng, quality, pm, translation, proto, design, devel, key, marketing, roadmap, blocker, spins, infrastructure, fpl
      }

      task event_deadline "Release Event Funding Request Deadline" {
        depends !logistics_budget {gaplength 1d}
        flags ambassadors
      }

      # Three weeks of public testing
      # Ends on a Monday and is followed by Final Release Deadline
      task beta_test "Beta Testing" {
        depends !stage_beta
        length 14d
        flags quality, proto
      }

      task websites_trans_reminder "Reminder to f-websites-list about POT/PO dates in 7 days" {
        depends !beta_drop
        flags translation, web
      }

      # two weeks to create
      # should be completely done and ready for hand off to Ambassadors two weeks before GA
      # Ambassadors should have made prior arrangements to flip artwork over to media producer
      # at this time.
      task media "Create DVD/CD label and sleeve artwork" {
        # not a "great" place to anchor to as it could move
        # needs to start four weeks before GA
        depends !beta_drop
        length 10d
        flags design
      }

      task testmile "End of Beta Testing" {
        depends !beta_test
        flags quality
      }

    }
  }  # E N D  of TestingPhase

  task LaunchPhase "Launch Phase" {

    # four weeks before GA, ambassadors create release posters
    # two weeks before GA to art team does final polish to posters
    # posters are ready on release day
    task release_posters "Release Party Posters" {
      depends !!TestingPhase.beta.beta_drop
      task create_posters "FAmSCo with Design Team Create Release Party Posters" {
        length 10d
        flags ambassadors
      }

      task polish_poster "Polish/Finalize Release Party Posters" {
        depends !create_posters
        length 9d
        flags design
      }
    }

    task screenshots "Update and freeze the screenshots page" {
      depends !!TestingPhase.beta.stage_beta {gaplength 5d}
      length 5d
      flags marketing
    }

    task final_screenshots "Marketing: Final Screen Shots" {
      depends !screenshots
      length 5d
      flags marketing
    }

    task briefings "Brief news distribution network" {
      depends !screenshots
      length 5d
      flags marketing
    }

    task monitor "Monitor news sites to provide corrections & info" {
      depends !screenshots
      length 29d
      flags marketing
    }

    task rc "Release Candidate" {

      task remind_final_blocker "Reminder: Final Blocker Meeting (${content}${major}blocker)" {
        precedes !final_blocker {gaplength 3d}
        length 1h
        flags pm
      }

      task final_blocker "Final Blocker Meeting (${content}${major}blocker)" {
        depends !remind_final_go_not
        flags releng, quality, devel, pm, blocker
      }

      task warn_unresolved_packages "Reminder: Warn maintainers with packages having broken deps these will be retired" {
        precedes !final_blocker {gaplength 12d}
        length 1h
        flags pm, releng
      }

      # two days before Final Deadline
      task shadow_before_final_deadline "SHADOW: one day before Final Deadline" {
        precedes !final_deadline {gaplength 1d}
        flags hidden
      }

      task kernel_debug "Disable Kernel debug and submit new Kernel build for RC" {
        depends !shadow_before_final_deadline
        flags devel
      }

      task final_deadline "Final Freeze${no_earlier} (00:00 UTC)" {
        depends !!!TestingPhase.beta.beta_test {gaplength 1d}
        flags releng, devel, proto, pm, key, spins
        PTask "https://fedoraproject.org/wiki/Milestone_freezes" { }
      }

      task fedora_branched_active "Set F${major} to active in Package database" {
        depends !final_deadline
        flags releng
      }

      task retire_broken_deps "Retire all packages with broken deps" {
        depends !final_deadline
        flags releng
      }

      task check_swag "FAmSCo and Regional Teams Meet to Address Unresolved Events/Media/Swag Issues" {
        depends !final_deadline {gaplength 1d}
        flags ambassadors
      }

      # one day before Final Deadline
      task final_wallpaper "Package Final Wallpaper" {
        depends !shadow_before_final_deadline
        flags design
      }

      # one day before Final Deadline
      task final_splash "Package Final Splash Screens" {
        depends !shadow_before_final_deadline
        flags design
      }

      task announce_final_change_deadline "Announce Final Freeze & Implications" {
        depends !final_deadline
        flags pm
      }

      # KEY ADJUSTMENT POINT--manually adjust if length of time before Final release ships changes
      task final_infrastructure_freeze "Final Infrastructure Change Freeze" {
        depends !!!TestingPhase.beta.beta_test {gaplength 1d}
        length 10d
        flags infrastructure, releng
      }

      task ga_release_notes "Final Release Notes" {

        # One day before public beta release
        task final_release_note_wiki_reminder "Reminder to Development: Wiki Freeze in 7 days" {
          depends !!!!TestingPhase.beta.shadow_before_beta_drop
          flags docs
        }

        task prep_ga_notes "Prepare GA Release Notes" {
          depends !!!!TestingPhase.beta.beta_drop
          flags docs, quality
        }

        task ga_release_notes_freeze "String Freeze: GA Release Notes" {
          depends !prep_ga_notes {gaplength 4d}
          flags docs
        }

        task wiki_ga_port "Port diff wiki content to Publican" {
          depends !ga_release_notes_freeze
          length 5d
          flags docs
        }

        task remind_trans_ga_notes "Remind Translation: RPM Freeze (no more POTs) in 5 days" {
          depends !ga_release_notes_freeze {gaplength 2d}
          flags docs
        }

        # KEY ADJUSTMENT POINT--if length of Beta changes this task length needs to change too
        task ga_pot_trans "Translate Final Release Notes (POT to PO)" {
          depends !!!!TestingPhase.beta.beta_release_notes.trans_release_notes_deadline {gaplength 1d}
          length 24d
          flags translation
        }

        task ga_release_notes_pot "Generate GA Release Notes POT files for Translation" {
          depends !wiki_ga_port
          flags docs
        }

        task build_trans_review_final "Build GA release note htmls for Translation" {
          depends !ga_release_notes_pot {gaplength 1d}
          length 4d
          flags docs
        }

        task build_ga_trans_review "Review and correct GA Release Notes (daily builds html)" {
          depends !ga_release_notes_pot {gaplength 1d}
          length 4d
          flags docs, translation
        }

        task remind_ga_trans_deadline "Remind Translators of GA Release Notes Deadline in 4 days" {
          depends !ga_release_notes_pot {gaplength 3d}
          flags docs
        }

        task ga_release_notes_po "Translation Deadline: GA rel-notes (PO Files complete)" {
          depends !ga_pot_trans
          flags translation
        }

        task ga_release_notes_rpm "Build fedora-release-notes.rpm" {
          depends !ga_release_notes_po
          length 2d
          flags docs
        }

      } #end final release notes


      # Three banners are created for the GA release (based on the Slogan from Marketing)
      # 1) large banner--fedoraproject.org front page
      # 2) "the release is out, go get it"--fedoraproject.org front page
      # 3) release name on start.fedoraproject.org
      # banners take one week to complete
      # banners should be completed one week before GA
      # banners are translated the week up until GA
      # translated during the week up until GA
      task ga_create_banners "Create Final Release Banners" {
        depends !!!TestingPhase.beta.testmile
        length 9d
        flags design
      }

      task wg_bullet_points_final "Email WGs to solicit bullet points for GA release announcement" {
        precedes !create_ga_announce {gaplength 5d}
        flags marketing
        length 1min
      }

      # Start one day before Final Freeze
      task create_ga_announce "Create GA Announcement (Docs & Marketing)" {
        depends !shadow_before_final_deadline
        length 7d
        flags docs, marketing
      }

      task translate_ga_announce "GA Announcement available for translation (optional)" {
        depends !create_ga_announce
        length 5d
        flags translation
      }

      task ga_publish_banners "Add Final Release Banners to Website" {
        depends !ga_create_banners
        length 1d
        flags web
      }

      # web propertities need to be updated and translated
      # Tasks start at time Beta Release goes out
      # http://fedoraproject.org/en/index
      # http://fedoraproject.org/en/get-fedora
      # http://fedoraproject.org/en/join-fedora
      # http://fedoraproject.org/en/get-help
      task web_content_update "Update Website Content" {
        depends !!!TestingPhase.beta.beta_drop
        length 5d
        flags web
      }

      task web_freeze "Website String Freeze" {
        depends !web_content_update
        flags web
      }

      task web_create_pot "Create Website POT Files" {
        depends !web_freeze
        length 1d
        flags web
      }

      task trans_web "Translation Period for Website (POT to PO)" {
        depends !web_create_pot
        length 9d
        flags translation
      }

      task review_trans_web "Review and correct Website translations" {
        depends !trans_web
        length 4d
        flags translation, web
      }

      task finish_trans_web "Translation Deadline: Websites (POs done)" {
        depends !review_trans_web
        flags translation
      }

      task publish_trans_web "Publish Translations on Website (fedoraproject.org)" {
        depends !review_trans_web
        length 1d
        flags web
      }

      task final_meeting_reminder "Reminder: Final Release Readiness Meeting" {
        depends !!!TestingPhase.beta.beta_test {gaplength 5d}
        flags pm
      }

      task ga_meeting "${content_title} ${major} Final Release Readiness Meeting" {
        depends !final_meeting_reminder {gaplength 3d}
        flags releng, pm, quality, docs, design, marketing, translation, web
      }

     task final_installer_build1 "Submit Installer Build for Final TC Compose" {
        depends !shadow_before_final_deadline
        flags devel
      }

      task create_final_tc "Create First 'Final' Test Compose (TC1)" {
        depends !shadow_before_final_deadline {gaplength 1d}
        flags releng, proto
      }

      task test_final_tc "Test 'Final' Test Compose (TC)" {
        depends !create_final_tc
        length 4d
        flags quality, proto
      }

      task early_iso "Regional Teams Obtain Final Release ISOs from Release Engineering for duplication" {
        depends !final_go_not {gaplength 2d}
        length 3d
        flags ambassadors
      }

      task regional_marketing "Regional Coordination with Marketing for Release Events" {
        depends !final_go_not {gaplength 2d}
        length 5d
        flags ambassadors
      }

      # for ics file
      task start_stage_final "Stage RC on matster minor" {
        depends !final_go_not
        flags releng
      }

      task notify_mirrors_final "Notify Mirrors of ${content_title} ${major} Final" {
        depends !start_stage_final {gaplength 1d}
        flags releng
      }


      task stage_final "Propagation of Alpha to mirrors" {
        depends !final_go_not
        length 3d
        flags releng, proto
      }

      task package_spins_ks "Branch spin-kickstarts and build package from new branch" {
        depends !create_final_tc
        flags spins
      }

      task freeze_spins_ks "Spins kickstart package Freeze" {
        depends !create_final_tc
        flags spins
      }

      task enable_updates "Enable ${content_title} ${major} Updates in Bodhi" {
        depends !!!TestingPhase.beta.beta_test {gaplength 2d}
        flags releng
      }

      task remind_final_go_not "Reminder: ${content_title} ${major} Final Go/No-Go Meeting" {
        depends !final_deadline {gaplength 4d}
        flags pm
      }

      task final_go_not "${content_title} ${major} Final Go/No-Go Meeting" {
        depends !final_deadline {gaplength 7d}
        flags releng, quality, docs, pm, proto, blocker
      }

      task common_bugs_page_final_update "'Common bugs' page to be updated" {
        depends !final_go_not {gaplength 1d}
        flags quality
        PTask "https://fedoraproject.org/wiki/Common_bugs" { }
      }

      # Zero-day tasks should start two Fridays before GA and finish the day before GA
      task zero_day_relnotes "Zero Day Release Notes" {

        task shadow_zero_day "SHADOW: Seven work week days before GA" {
          precedes !!!ga {gaplength 7d}
          flags hidden
        }

        task zero_day_web "0-Day rel-notes update docs.fp.org" {
          depends !shadow_zero_day
          length 6d
          flags docs
        }

        task zero_day_rpm "0-Day rel-notes build updated rpm" {
          depends !shadow_zero_day
          length 6d
          flags docs
        }

        task zero_day_pot "0-Day rel-notes generate POT" {
          depends !shadow_zero_day
          length 6d
          flags docs
        }

        task zero_day_trans "Translate 0-Day Release Notes" {
          depends !shadow_zero_day
          length 6d
          flags translation
        }

        task zero_day_deadline "Translation Deadline: 0-Day (PO Files complete)" {
          depends !zero_day_trans
          flags translation
        }

        task web_post "Add translated zero-day updates to docs.fp.org" {
          depends !zero_day_trans
          flags docs
        }

        task post_tech_notes "Update and post Fedora Technical Notes to docs.fedoraproject.org" {
          depends !!!ga
          flags docs
        }

        # Monday after Tuesday GA
        task push_updates_rpm "Push updated rel-notes RPMs to Updates repo" {
          depends !!!ga {gaplength 4d}
          flags docs
        }

      } # zero_day_relnotes

    } # end of rc task

    # Required for product pages--do not change description
    # Also make sure to confirm this date with Red Hat IS to
    # make sure it does not conflict with other releases.  This should
    # generally not be a problem because of:
    # https://fedoraproject.org/wiki/Infrastructure/Red_Hat_bandwidth_effects
    # Do NOT change the name of this task
    task ga "GA" {
      depends !rc.stage_final
      flags hidden, roadmap
    }

    task blocker_bug_tracker_update "Blocker bug tracker update" {
        depends !ga {gaplength 1d}
        flags quality
        PTask "https://qa.fedoraproject.org/blockerbugs/" { }
    }

    task bugzilla_descrption "Reflect supported versions in Bugzilla product description" {
      depends !rc.stage_final
      flags pm
    }

    task final "Final Release Public Availability (GA)${no_earlier}" {
      depends !rc.stage_final
      flags quality, releng, docs, design, pm, translation, proto, devel, key, marketing, roadmap, spins, infrastructure, fpl
      PTask "https://fedoraproject.org/wiki/Fedora_24_Final_Release_Criteria" { }
    }

    # Elections, once the release is made public
    task elections "Elections" {
        flags elections
        PTask "https://fedoraproject.org/wiki/Elections" { }
        depends !ga {gapduration 6d}

        task wiki "Preparation of Elections wiki page" {
            flags elections, pm
            length 5d
            PTask "https://fedoraproject.org/wiki/Elections"
        }

        task questionnaire "Preparation of Questionnaire for candidates" {
            flags elections, pm
            length 5d
            PTask "https://fedoraproject.org/wiki/Elections/Questionnaire"
        }

        task nominations_pages "Preparation of Nominations pages" {
            flags elections, pm
            length 5d
        }

        task nomination_starts "SHADOW: Nomination period starts" {
            flags elections, hidden
            depends !wiki {gapduration 1d}, !questionnaire {gapduration 1d}, !nominations_pages {gapduration 1d}
        }

        task nomination_reminder "REMINDER: Notification 'Nomination period starts' sent to mailing lists" {
            depends !nomination_starts
            flags elections, pm
            note "devel-announce@lists.fedoraproject.org, announce@lists.fedoraproject.org"
        }

        task nomination_period "Nomination period" {
            duration 6d
            depends !nomination_starts
            flags elections
        }

        task campaign_reminder "REMINDER: Notification 'Campaign period starts' sent to mailing lists" {
            depends !nomination_period {gapduration 1d}
            flags elections, pm
            note "devel-announce@lists.fedoraproject.org, announce@lists.fedoraproject.org"
        }

        task campaign_period "Campaign period" {
            duration 6d
            depends !nomination_period {gapduration 1d}
            flags elections
        }
        task voting_setup "Setup of Voting machine" {
            duration 6d
            depends !nomination_period {gapduration 1d}
            flags elections, pm
            PTask "https://admin.fedoraproject.org/voting/"
        }
        task voting_reminder "REMINDER: Notification 'Voting period starts' sent to mailing lists" {
            depends !campaign_period {gapduration 1d}
            flags elections, pm
            note "devel-announce@lists.fedoraproject.org, announce@lists.fedoraproject.org"
        }

        task voting_period "Voting period" {
            duration 6d
            depends !campaign_period {gapduration 1d}
            flags elections
        }
        task results_announcement "Result Announcement" {
            milestone
            depends !voting_period {gapduration 1d}
            flags elections, pm
            note "devel-announce@lists.fedoraproject.org, announce@lists.fedoraproject.org"
        }
    }

    # ADJUST FOR NEW RELEASE--EOL Version
    task remind_eol "Send Email Reminder About Fedora 22 EOL Activities" {
      depends !ga {gaplength 2d}
      flags releng, pm, devel
    }

    task event_reports "Hold Sponsored Release Events and Publish Event Reports" {
      depends !ga
      length 23d
      flags ambassadors
    }

    task spins_ga_ks "Build new spin-kickstarts package for updates (if necessary)" {
      depends !rc.stage_final
      flags spins
    }

    task marketing_post "Marketing Retrospective" {
      depends !final
      length 10d
      flags marketing
    }
  }

  /*
  # ADJUST FOR NEW RELEASE

  # manually set end date of maintenance based on...
  task MaintenancePhase "Maintenance Phase" {

  }
  */

  # Starting in Fedora 13, the docs group wanted the Guides work to span almost
  # the entire release cycle--they don't fit nicely into different phases.
  # So I'm putting them all here in their own block.

  # Run from Start until one week before GA
  task all_guides "${content_title} ${major} Guides" {

    # Run from Start until "Branch Guides"
    task continue_guides_trans "Continue translation of guides in branch of previous release " {
      length 70d
      flags translation
    }


    task test_branch_guides "Test master branches of guides against Alpha and correct" {
      depends !!TestingPhase.alpha.stage_alpha
      length 15d
      flags docs
    }

    task branch_guides "Branch Guides" {
      depends !test_branch_guides
      flags docs
    }

    task guides_pot "Create POT files for All Guides" {
      depends !branch_guides
      flags docs
    }

    task notify_trans "Notify trans that new Guide POT files available " {
      depends !guides_pot
      flags docs
    }

    task trans_all_guides "Translate All Guides (POT to PO)" {
      depends !guides_pot
      flags docs
    }

    task publish_draft "Publish draft guides" {
      depends !branch_guides
      flags docs
    }

    task annouce_publish_draft "Notify announce-list and f-devel-list draft guides available" {
      depends !publish_draft
      flags docs
    }


    # ADJUST FOR NEW RELEASE--make sure this task lands one day before GA
    task guides_trans "Translate All Guides (POT to PO)" {
      depends !guides_pot
      length 39d
      flags translation
    }

    task remind_trans_pot "Reminder to Trans that new POT files are coming for all guides" {
      depends !!TestingPhase.alpha.stage_alpha {gaplength 13d}
      flags docs
    }

    # Wednesday, one week after Beta Freeze
    task srpm_review "Remind new guide owners SRPM package review" {
      depends !!TestingPhase.beta.beta_deadline {gaplength 6d}
      flags docs
    }

    task shadow_before_beta_deadline "SHADOW: for Friday before Beta deadline" {
      precedes !!TestingPhase.beta.beta_deadline {gaplength 1d}
      flags hidden
    }

    # Friday before Final Freeze
    task remind_trans "Reminder to Trans that Final Guides POT files are coming" {
      depends !shadow_before_beta_deadline
      flags docs
    }

    task guides_string_freeze "String Freeze All Guides" {
      depends !!LaunchPhase.rc.final_deadline
      flags docs
    }

    task generate_final_pot "Generate final POT files for Guides" {
      depends !guides_string_freeze
      flags docs
    }

    task notify_trans_final "Notify Trans of Final Guides POT availability" {
      depends !guides_string_freeze
      flags docs
    }

    # Monday to Friday, two weeks before GA
    task build_daily "Daily builds of Final guides for Translation" {
      length 9d
      depends !!LaunchPhase.rc.final_deadline
      flags docs
    }

    # Monday to Friday, two weeks before GA
    task review_daily "Review and correct Final Translated Guides (daily builds html)" {
      depends !!LaunchPhase.rc.final_deadline
      length 9d
      flags translation
    }

    # Friday before GA
    task shadow_guides_trans_deadline "SHADOW: Translation Deadline: All Final Guides" {
      precedes !!LaunchPhase.ga {gaplength 2d}
      flags hidden
    }

    # zero duration tasks (milestones/deadlines) need a shadow preceds task so they report correctly
    # Also needed for ICS files which only report milestones
    task guides_trans_deadline "Translation Deadline: All Final Guides" {
      depends !shadow_guides_trans_deadline
      flags translation
    }

    task test_guides_beta "Test guides against Beta and correct" {
      depends !!TestingPhase.beta.beta_drop
      length 4d
      flags docs
    }

    task refresh_pot "Refresh POT files for all guides against Beta" {
      depends !test_guides_beta
      flags docs
    }

    task notify_trans_refresh "Notify trans that POT files updated against Beta" {
      depends !refresh_pot
      flags docs
    }

    task republish_draft "Republish draft guides for Beta" {
      depends !test_guides_beta
      flags docs
    }

    task notify_revised_draft "Notify announce-list and f-devel-list revised draft guides available" {
      depends !republish_draft
      flags docs
    }

    # Friday before GA until the day before GA
    task guides_final_build "Final Build All Guides: All Languages" {
      depends !srpm_review
      length 3d
      flags docs
    }

    # Day before GA
    task shadow_publish_guides "SHADOW: Publish all guides to docs.fp.o (html,html-single,pdf)" {
      precedes !!LaunchPhase.ga {gaplength 2d}
      flags hidden
    }

    task publish_guides "Publish all guides to docs.fp.o (html,html-single,pdf)" {
      depends !shadow_publish_guides

      flags docs
    }

  } # end of "all_guides"

  task pr "Public Relations" {

    task video "Creative team videos" {
      flags fpl, pr

      task video_schedule "Meet w/Creative to schedule videos" {
        precedes !video1.review_spotlight1_video {gaplength 25d}
        length 5d
      }

      task video1 "Make spotlight video #1" {
        task review_spotlight1_video "Review video #1" {
          precedes !release_spotlight1_video
          length 15d
        }

        task release_spotlight1_video "Publish spotlight video #1" {
          depends !!!spotlight_feature_blogs.spotlight_feature1.spotlight_feature1_drop
        }
      }

      task video2 "Make spotlight video #2" {
        task review_spotlight2_video "Review video #2" {
          precedes !release_spotlight2_video
          length 15d
        }

        task release_spotlight2_video "Publish spotlight video #2" {
          depends !!!spotlight_feature_blogs.spotlight_feature3.spotlight_feature3_drop
        }
      }

      task release_video "Make release video" {
        task review_release_video "Review release video" {
          precedes !release_video
          length 20d
        }

        task release_video "Publish release video" {
          depends !!!!LaunchPhase.final
        }
      }

    } #end video

    task beta_release_blog "Beta press blog entry" {
      flags fpl, pr
      /**
      * By building the final task to be a 0-duration event
      * (milestone), depending on another given task date like a
      * release date, and having each other task below precede the
      * one following, these tasks should auto-adjust to fall on a
      * given date.
      */


      task beta_release_blog_draft "Start drafting Beta blog" {
        precedes !beta_release_blog_legal
        length 10d
      }

      task beta_release_blog_legal "Red Hat PR send Beta blog to Legal" {
        precedes !beta_release_blog_intl
        length 5d
      }

      task beta_release_blog_intl "Red Hat PR send Beta blog to intl-pr list" {
        precedes !beta_release_blog_drop
        length 6d
      }

      task beta_release_blog_drop "Red Hat PR publish and send Beta blog to media contacts" {
        depends !!!TestingPhase.beta.beta_drop
      }
    }

    task spotlight_feature_blogs "Spotlight feature press blogs" {
      task spotlight_feature1 "Spotlight feature #1" {
        task spotlight_feature1_draft "Draft spotlight #1 blog entry" {
          precedes !spotlight_feature1_legal
          length 5d
          flags fpl, pr
        }

        task spotlight_feature1_legal "Red Hat PR send spotlight #1 blog entry draft to legal" {
          precedes !spotlight_feature1_drop
          length 5d
          flags fpl, pr
        }

        task shadow_spotlight_feature1 "SHADOW: Three weeks until GA" {
          precedes !!!!LaunchPhase.final { gaplength 16d }
          length 1d
          flags hidden
        }

        task spotlight_feature1_drop "Red Hat PR publish spotlight #1 blog entry" {
          depends !shadow_spotlight_feature1
          flags fpl, pr
        }

      }

      task spotlight_feature2 "Spotlight feature #2" {
        task spotlight_feature2_draft "Draft spotlight #2 blog entry" {
          precedes !spotlight_feature2_legal
          length 5d
          flags fpl, pr
        }

        task spotlight_feature2_legal "Red Hat PR send spotlight #2 blog entry draft to legal" {
          precedes !spotlight_feature2_drop
          length 5d
          flags fpl, pr
        }

        task spotlight_feature2_drop "Red Hat PR publish spotlight #2 blog entry" {
          depends !shadow_spotlight_feature2
          flags fpl, pr
        }

        task shadow_spotlight_feature2 "SHADOW: Two weeks until GA" {
          precedes !!!!LaunchPhase.final { gaplength 11d }
          length 1d
          flags hidden
        }
      }

      task spotlight_feature3 "Spotlight feature #3" {
        task spotlight_feature3_draft "Draft spotlight #3 blog entry" {
          precedes !spotlight_feature3_legal
          length 5d
          flags fpl, pr
        }

        task spotlight_feature3_legal "Red Hat PR send spotlight #3 blog entry draft to legal" {
          precedes !spotlight_feature3_drop
          length 5d
          flags fpl, pr
        }

        task spotlight_feature3_drop "Red Hat PR publish spotlight #3 blog entry" {
          depends !shadow_spotlight_feature3
          flags fpl, pr
        }

        task shadow_spotlight_feature3 "SHADOW: One week until GA" {
          precedes !!!!LaunchPhase.final { gaplength 6d }
          duration 1d
          flags hidden
        }
      }
    }

    task usb_keys_prebriefs "USB Keys and media pre-briefs" {
      flags fpl, pr

      task buy_usb_keys "Purchase USB Keys" {
        precedes !prepare_usb_keys
        length 5d
      }

      task assess_press_kit "Check LiveUSB press review sheet for readiness" {
        precedes !update_press_one_sheet
        length 5d
      }

      task update_press_one_sheet "Update LiveUSB press review sheet" {
        precedes !send_usb_keys
        length 5d
      }

      task prepare_usb_keys "Prep USB keys with pre-release" {
        precedes !send_usb_keys
        length 5d
      }

      task send_usb_keys "Send USB keys to Red Hat PR for distribution" {
        precedes !media_prebriefs {gaplength 10d}
        length 3d
      }

      task distribute_usb_keys "Red Hat PR distribute USB keys to media contacts" {
        precedes !media_prebriefs {gaplength 7d}
        length 5d
      }

      task media_prebriefs "Hold media prebrief interviews" {
        precedes !!!LaunchPhase.final
        length 6d
      }
    }

    task redhat_com_update "Update Red Hat web site" {
      flags fpl, pr

      task web_graphics_discuss "Schedule meeting with Red Hat web team to plan launch" {
        length 5d
        precedes !web_promo_to_brand
      }

      task web_promo_to_brand "Send web promo ideas to Brand" {
        length 5d
        precedes !web_copy_review
      }

      task web_copy_review "Review and update www.redhat.com/Fedora copy" {
        length 5d
        precedes !web_copy_send_update
      }

      task web_copy_send_update "Send updated copy to Web team" {
        precedes !rh_web_goes_live { gaplength 11d }
        length 5d
      }

      task rh_web_goes_live "Red Hat website changes go live" {
        depends !!!LaunchPhase.final
      }
    }

    task ga_press_release "GA press release" {
      flags fpl, pr

      task ga_press_release_draft "Start drafting GA press release" {
        length 10d
        precedes !ga_press_release_legal
      }

      task ga_press_release_legal "Red Hat PR send GA press release to Legal" {
        length 5d
        precedes !ga_press_release_intl
      }

      task ga_press_release_intl "Red Hat PR send GA press release to intl-pr list" {
        length 6d
        precedes !ga_press_release_drop
      }

      task ga_press_release_drop "Red Hat PR publish and send GA press release to media contacts" {
        depends !!!LaunchPhase.final
      }
    }

    task ceo_blog "CEO press blog entry" {
      flags fpl, pr

      task ceo_prepare_final_rc "Prepare a final RC on USB for CEO" {
        precedes !ceo_send_final_rc
        length 2d
      }

      task ceo_send_final_rc "Send final RC USB key to CEO" {
        precedes !ceo_solicit_feedback
        length 2d
      }

      task ceo_solicit_feedback "Solicit CEO feedback on pre-release" {
        precedes !ceo_blog_draft
        length 4d
      }

      task ceo_blog_draft "Draft CEO blog" {
        precedes !ceo_blog_legal
        length 3d
      }

      task ceo_blog_legal "Red Hat PR send CEO blog to Legal" {
        precedes !ceo_blog_drop
        length 3d
      }

      task ceo_blog_drop "Red Hat PR publish and send CEO blog to media contacts" {
        depends !!!LaunchPhase.final {gaplength 1d}
      }
    }
  }

} # Bitter End
